# empreendimento_industrial

Schedule from MS Project, 2011-04-13 to 2015-07-21, costs in R$.

## Calendars

- Padrão: Mon-Fri 09:00-12:00, 13:00-18:00; Sat-Sun off.

## Resources

| Resource |
| --- |
| 1000000 |
| 300000 |
| 500000 |

## Schedule

| ID | WBS | Task | Duration | Start | Finish | Predecessors | Total slack | Cost |
| --- | --- | --- | --- | --- | --- | --- | --- | --- |
| 1 | 1 | **Empreendimento Industrial** | 1115d | 2011-04-13 | 2015-07-21 |  | 0d | 3,100,000 |
| 2 | 1.1 | **Engenharia** | 530d | 2011-04-13 | 2013-04-23 |  | 0d | 1,800,000 |
| 3 | 1.1.1 | Conceitual | 100d | 2011-04-13 | 2011-08-30 |  | 0d | 1,000,000 |
| 4 | 1.1.2 | Basica | 150d | 2011-08-31 | 2012-03-27 | 3 | 0d | 300,000 |
| 5 | 1.1.3 | Detalhada | 280d | 2012-03-28 | 2013-04-23 | 4 | 0d | 500,000 |
| 6 | 1.2 | **Suprimentos** | 400d | 2012-03-28 | 2013-10-08 |  | 280d | 500,000 |
| 7 | 1.2.1 | Operacionais | 70d | 2012-03-28 | 2012-07-03 | 4 | 795d | 100,000 |
| 8 | 1.2.2 | Materiais | 120d | 2013-04-24 | 2013-10-08 | 5 | 0d | 250,000 |
| 9 | 1.2.3 | Servicos | 110d | 2012-03-28 | 2012-08-28 | 4 | 290d | 150,000 |
| 10 | 1.3 | **Construcao** | 250d | 2013-10-09 | 2014-09-23 |  | 0d | 255,000 |
| 11 | 1.3.1 | Eqptos | 200d | 2013-10-09 | 2014-07-15 | 8 | 265d | 100,000 |
| 12 | 1.3.2 | Primeira Fase | 100d | 2013-10-09 | 2014-02-25 | 8, 9 | 0d | 75,000 |
| 13 | 1.3.3 | Segunda Fase | 150d | 2014-02-26 | 2014-09-23 | 12 | 0d | 80,000 |
| 14 | 1.4 | **Montagem** | 90d | 2014-09-24 | 2015-01-27 |  | 0d | 270,000 |
| 15 | 1.4.1 | Canteiro | 50d | 2014-09-24 | 2014-12-02 | 13 | 0d | 120,000 |
| 16 | 1.4.2 | Terceiros | 25d | 2014-12-03 | 2015-01-06 | 15 | 140d | 100,000 |
| 17 | 1.4.3 | Movimentacoes | 40d | 2014-12-03 | 2015-01-27 | 15 | 0d | 50,000 |
| 18 | 1.5 | **Pre-operacao** | 35d | 2015-01-28 | 2015-03-17 |  | 0d | 60,000 |
| 19 | 1.5.1 | Testes | 15d | 2015-01-28 | 2015-02-17 | 17 | 0d | 25,000 |
| 20 | 1.5.2 | Partida Assistida | 20d | 2015-02-18 | 2015-03-17 | 19 | 90d | 35,000 |
| 21 | 1.6 | **Encerramento** | 110d | 2015-02-18 | 2015-07-21 |  | 0d | 215,000 |
| 22 | 1.6.1 | As-built | 100d | 2015-02-18 | 2015-07-07 | 19 | 0d | 200,000 |
| 23 | 1.6.2 | Entrega Tecnica | 10d | 2015-07-08 | 2015-07-21 | 22 | 0d | 15,000 |
